| id | name | startDate | endDate | priority | barScale | progress | type | parentId | dependencies |
| --- | --- | --- | --- | --- | --- | --- | --- | --- | --- |
| 1 | Planification d'Événements | 2026-06-01T00:00:00.000Z | 2026-08-10T00:00:00.000Z | medium | 1 | 0 | group |  |  |
| 2 | Définir les objectifs et indicateurs de réussite | 2026-06-01T00:00:00.000Z | 2026-06-06T00:00:00.000Z | high | 1 | 0 | task | 1 |  |
| 3 | Fixer le budget de l'événement | 2026-06-04T00:00:00.000Z | 2026-06-11T00:00:00.000Z | medium | 1 | 0 | task | 1 |  |
| 4 | Présélectionner et visiter des lieux | 2026-06-06T00:00:00.000Z | 2026-06-15T00:00:00.000Z | medium | 1 | 0 | task | 1 | 2 FS |
| 5 | Réserver le lieu et confirmer la date | 2026-06-15T00:00:00.000Z | 2026-06-16T00:00:00.000Z | high | 1 | 0 | milestone | 1 | 4 FS |
| 6 | Réserver le traiteur et finaliser le menu | 2026-06-16T00:00:00.000Z | 2026-06-28T00:00:00.000Z | medium | 1 | 0 | task | 1 | 5 FS |
| 7 | Réserver le prestataire audiovisuel | 2026-06-16T00:00:00.000Z | 2026-06-26T00:00:00.000Z | medium | 1 | 0 | task | 1 | 5 FS |
| 8 | Réserver les locations (mobilier, tente, décor) | 2026-06-16T00:00:00.000Z | 2026-06-26T00:00:00.000Z | medium | 1 | 0 | task | 1 | 5 FS |
| 9 | Rédiger le déroulé de l'événement | 2026-06-21T00:00:00.000Z | 2026-07-01T00:00:00.000Z | medium | 1 | 0 | task | 1 | 5 FS |
| 10 | Lancer inscriptions et invitations | 2026-06-29T00:00:00.000Z | 2026-07-06T00:00:00.000Z | medium | 1 | 0 | task | 1 | 5 FS |
| 11 | Mener la campagne marketing et promotion | 2026-06-29T00:00:00.000Z | 2026-07-19T00:00:00.000Z | medium | 1 | 0 | task | 1 | 5 FS |
| 12 | Suivre confirmations, repas et accessibilité | 2026-07-06T00:00:00.000Z | 2026-07-26T00:00:00.000Z | medium | 1 | 0 | task | 1 | 10 FS |
| 13 | Recruter et confirmer personnel/bénévoles | 2026-07-06T00:00:00.000Z | 2026-07-20T00:00:00.000Z | high | 1 | 0 | task | 1 |  |
| 14 | Finaliser plan de salle, signalétique, montage | 2026-07-13T00:00:00.000Z | 2026-07-27T00:00:00.000Z | medium | 1 | 0 | task | 1 | 8 FS |
| 15 | Briefer personnel et bénévoles sur leur rôle | 2026-07-20T00:00:00.000Z | 2026-07-23T00:00:00.000Z | medium | 1 | 0 | task | 1 | 13 FS |
| 16 | Confirmer le nombre final avec prestataires | 2026-07-26T00:00:00.000Z | 2026-07-27T00:00:00.000Z | high | 1 | 0 | milestone | 1 | 12 FS |
| 17 | Visite finale du lieu | 2026-07-27T00:00:00.000Z | 2026-07-29T00:00:00.000Z | medium | 1 | 0 | task | 1 | 16 FS |
| 18 | Jour J | 2026-08-03T00:00:00.000Z | 2026-08-04T00:00:00.000Z | high | 1 | 0 | milestone | 1 | 17 FS |
| 19 | Envoyer les remerciements | 2026-08-04T00:00:00.000Z | 2026-08-07T00:00:00.000Z | medium | 1 | 0 | task | 1 | 18 FS |
| 20 | Bilan et rapport de clôture | 2026-08-07T00:00:00.000Z | 2026-08-10T00:00:00.000Z | medium | 1 | 0 | task | 1 | 19 FS |
